# Microsoft Office Project - Das Profibuch

Schedule from MS Project, 2007-02-25 to 2007-04-05, costs in €.
Kapitel 11 - VBA Tutorium

## Calendars

- Standard: Mon-Fri 08:00-12:00, 13:00-17:00; Sat-Sun off.

## Resources

| Resource | Group | Rate |
| --- | --- | --- |
| Matthias Jäger | Programmierer | 100 |
| Steffen Reister | Marketing | 100 |
| Renke Holert | Consultant | 100 |
| Helmut Reinke | Netzwerk Spezialist | 100 |
| Egbert Jeschke | Graphiker | 100 |

## Schedule

| ID | WBS | Task | Type | Duration | Start | Finish | Predecessors | Baseline start | Baseline finish | Baseline duration | Total slack | Free slack | Resources | Work | Cost | Baseline cost | KW mit VBA | KW mit Formel |
| --- | --- | --- | --- | --- | --- | --- | --- | --- | --- | --- | --- | --- | --- | --- | --- | --- | --- | --- |
| 1 | 1 | Start | milestone | 0d | 2007-02-25 | 2007-02-25 |  |  |  |  | 29d |  |  |  |  |  | KW 9 | KW9 |
| 2 | 2 | **Initialisierung** |  | 2d | 2007-02-25 | 2007-02-27 |  | 2002-07-01 | 2002-07-02 | 2d | 0d |  |  | 16h | 1,600 | 1,600 | KW 9 | KW9 |
| 3 | 2.1 | Auftrag erteilt | milestone | 0d | 2007-02-25 | 2007-02-25 |  | 2002-07-01 | 2002-07-01 | 0d | 0d |  |  |  |  |  | KW 9 | KW9 |
| 4 | 2.2 | Marketingkonzept erstellen |  | 2d | 2007-02-26 | 2007-02-27 | 3 | 2002-07-01 | 2002-07-02 | 2d | 0d |  | Matthias Jäger | 16h | 1,600 | 1,600 | KW 9 | KW9 |
| 5 | 3 | **Entwurf Prototyp** |  | 6d? | 2007-02-28 | 2007-03-07 |  | 2002-07-03 | 2002-07-10 | 6d | 0d |  |  | 64h | 6,400 | 5,600 | KW 9 | KW9 |
| 6 | 3.1 | Designkonzept |  | 2d | 2007-02-28 | 2007-03-01 | 4 | 2002-07-03 | 2002-07-04 | 2d | 0d |  | Matthias Jäger | 16h | 1,600 | 1,600 | KW 9 | KW9 |
| 7 | 3.2 | Navigationskonzept |  | 2d | 2007-03-02 | 2007-03-05 | 6 | 2002-07-05 | 2002-07-08 | 2d | 0d |  | Renke Holert | 16h | 1,600 | 1,600 | KW 9 | KW9 |
| 8 | 3.3 | Implementationskonzept |  | 1d? | 2007-03-06 | 2007-03-06 | 7 | 2002-07-09 | 2002-07-09 | 1d | 0d |  | Helmut Reinke | 8h | 800 | 800 | KW 10 | KW10 |
| 9 | 3.4 | Betriebskonzept |  | 1d? | 2007-03-06 | 2007-03-06 | 8SS | 2002-07-09 | 2002-07-09 | 1d | 0d |  | Steffen Reister | 8h | 800 | 800 | KW 10 | KW10 |
| 10 | 3.5 | Konzeptpräsentation |  | 1d? | 2007-03-07 | 2007-03-07 | 8, 9 | 2002-07-10 | 2002-07-10 | 1d | 0d |  | Steffen Reister; Matthias Jäger | 16h | 1,600 | 800 | KW 10 | KW10 |
| 11 | 3.6 | Abnahme Prototyp | milestone | 0d? | 2007-03-07 | 2007-03-07 | 10 | 2002-07-10 | 2002-07-10 | 0d | 0d |  |  |  |  |  | KW 10 | KW10 |
| 12 | 4 | Meilenstein 1 | milestone | 0d | 2007-03-07 | 2007-03-07 | 11 |  |  |  | 0d |  |  |  |  |  | KW 10 | KW10 |
| 13 | 5 | **Realisierung** |  | 21d | 2007-03-08 | 2007-04-05 |  | 2002-07-11 | 2002-08-02 | 17d | 0d |  |  | 640h | 64,000 | 47,200 | KW 10 | KW10 |
| 14 | 5.1 | ToDo Liste erstellen |  | 1d | 2007-03-08 | 2007-03-08 | 12 | 2002-07-11 | 2002-07-11 | 1d | 0d |  | Matthias Jäger | 8h | 800 | 800 | KW 10 | KW10 |
| 15 | 5.2 | Inhalte erstellen |  | 15d | 2007-03-09 | 2007-03-29 | 14 | 2002-07-12 | 2002-08-01 | 15d | 5d |  | Renke Holert; Steffen Reister; Matthias Jäger | 360h | 36,000 | 36,000 | KW 10 | KW10 |
| 16 | 5.3 | Programmierung |  | 17d | 2007-03-14 | 2007-04-05 | 14FS+3d | 2002-07-17 | 2002-08-02 | 13d | 0d |  | Matthias Jäger; Egbert Jeschke | 272h | 27,200 | 10,400 | KW 11 | KW11 |
| 17 | 5.4 | Website erstellt | milestone | 0d | 2007-04-05 | 2007-04-05 | 15, 16 | 2002-08-02 | 2002-08-02 | 0d | 0d |  |  |  |  |  | KW 14 | KW14 |
| 18 | 6 | **Abnahme** |  | 5d? | 2007-02-26 | 2007-03-02 |  | 2002-08-05 | 2002-08-08 | 3.5d | 24d |  |  | 48h | 4,800 | 3,600 | KW 9 | KW9 |
| 19 | 6.1 | Abnahmedokument |  | 1d | 2007-02-26 | 2007-02-26 |  | 2002-08-05 | 2002-08-05 | 1d | 24d | 0d | Renke Holert | 8h | 800 | 800 | KW 9 | KW9 |
| 20 | 6.2 | Testlauf |  | 1d? | 2007-02-27 | 2007-02-27 | 19 | 2002-08-06 | 2002-08-06 | 1d | 24d | 0d | Matthias Jäger; Helmut Reinke | 16h | 1,600 | 1,600 | KW 9 | KW9 |
| 21 | 6.3 | Fehlerbehebung |  | 1d | 2007-02-28 | 2007-02-28 | 20 | 2002-08-07 | 2002-08-07 | 1d | 24d | 0d | Matthias Jäger | 8h | 800 | 800 | KW 9 | KW9 |
| 22 | 6.4 | Liveschaltung der Website |  | 2d | 2007-03-01 | 2007-03-02 | 21 | 2002-08-08 | 2002-08-08 | 0.5d | 24d | 0d | Steffen Reister | 16h | 1,600 | 400 | KW 9 | KW9 |
| 23 | 6.5 | Projektabschluss | milestone | 0d | 2007-03-02 | 2007-03-02 | 22 | 2002-08-08 | 2002-08-08 | 0d | 24d | 0d |  |  |  |  | KW 9 | KW9 |
| 24 | 7 | Ende | milestone | 0d | 2007-03-02 | 2007-03-02 | 23 |  |  |  | 24d |  |  |  |  |  | KW 9 | KW9 |
