# Microsoft Office Project - Das Profibuch

Schedule from MS Project, 2007-02-25 to 2007-04-05, costs in €.
Kapitel 11 - VBA Tutorium

## Calendars

- Standard: Mon-Fri 08:00-12:00, 13:00-17:00; Sat-Sun off.

## Resources

| Resource | Group | Rate |
| --- | --- | --- |
| Matthias Jäger | Programmierer | 100 |
| Steffen Reister | Marketing | 100 |
| Renke Holert | Consultant | 100 |
| Helmut Reinke | Netzwerk Spezialist | 100 |
| Egbert Jeschke | Graphiker | 100 |

## Schedule

| ID | WBS | Task | Type | Duration | Start | Finish | Predecessors | Baseline start | Baseline finish | Baseline duration | Total slack | Resources | Work | Cost | Baseline cost | Text1 |
| --- | --- | --- | --- | --- | --- | --- | --- | --- | --- | --- | --- | --- | --- | --- | --- | --- |
| 1 | 1 | **Initialisierung** |  | 2d | 2007-02-25 | 2007-02-27 |  | 2002-07-01 | 2002-07-02 | 2d | 0d |  | 16h | 1,600 | 1,600 | 188743752 |
| 2 | 1.1 | Auftrag erteilt | milestone | 0d | 2007-02-25 | 2007-02-25 |  | 2002-07-01 | 2002-07-01 | 0d | 0d |  |  |  |  | 188743753 |
| 3 | 1.2 | Marketingkonzept erstellen |  | 2d | 2007-02-26 | 2007-02-27 | 2 | 2002-07-01 | 2002-07-02 | 2d | 0d | Matthias Jäger | 16h | 1,600 | 1,600 | 188743754 |
| 4 | 2 | **Entwurf Prototyp** |  | 6d? | 2007-02-28 | 2007-03-07 |  | 2002-07-03 | 2002-07-10 | 6d | 0d |  | 64h | 6,400 | 5,600 | 188743755 |
| 5 | 2.1 | Designkonzept |  | 2d | 2007-02-28 | 2007-03-01 | 3 | 2002-07-03 | 2002-07-04 | 2d | 0d | Matthias Jäger | 16h | 1,600 | 1,600 | 188743756 |
| 6 | 2.2 | Navigationskonzept |  | 2d | 2007-03-02 | 2007-03-05 | 5 | 2002-07-05 | 2002-07-08 | 2d | 0d | Renke Holert | 16h | 1,600 | 1,600 | 188743757 |
| 7 | 2.3 | Implementationskonzept |  | 1d? | 2007-03-06 | 2007-03-06 | 6 | 2002-07-09 | 2002-07-09 | 1d | 0d | Helmut Reinke | 8h | 800 | 800 | 188743758 |
| 8 | 2.4 | Betriebskonzept |  | 1d? | 2007-03-06 | 2007-03-06 | 7SS | 2002-07-09 | 2002-07-09 | 1d | 0d | Steffen Reister | 8h | 800 | 800 | 188743759 |
| 9 | 2.5 | Konzeptpräsentation |  | 1d? | 2007-03-07 | 2007-03-07 | 7, 8 | 2002-07-10 | 2002-07-10 | 1d | 0d | Steffen Reister; Matthias Jäger | 16h | 1,600 | 800 | 188743760 |
| 10 | 2.6 | Abnahme Prototyp | milestone | 0d? | 2007-03-07 | 2007-03-07 | 9 | 2002-07-10 | 2002-07-10 | 0d | 0d |  |  |  |  | 188743761 |
| 11 | 3 | **Realisierung** |  | 17d | 2007-03-08 | 2007-03-30 |  | 2002-07-11 | 2002-08-02 | 17d | 0d |  | 576h | 57,600 | 47,200 | 188743972 |
| 12 | 3.1 | ToDo Liste erstellen |  | 1d | 2007-03-08 | 2007-03-08 | 10 | 2002-07-11 | 2002-07-11 | 1d | 0d | Matthias Jäger | 8h | 800 | 800 | 188743973 |
| 13 | 3.2 | Inhalte erstellen |  | 15d | 2007-03-09 | 2007-03-29 | 12 | 2002-07-12 | 2002-08-01 | 15d | 1d | Renke Holert; Steffen Reister; Matthias Jäger | 360h | 36,000 | 36,000 | 188743974 |
| 14 | 3.3 | Programmierung |  | 13d | 2007-03-14 | 2007-03-30 | 12FS+3d | 2002-07-17 | 2002-08-02 | 13d | 0d | Matthias Jäger; Egbert Jeschke | 208h | 20,800 | 10,400 | 188743975 |
| 15 | 3.4 | Website erstellt | milestone | 0d | 2007-03-30 | 2007-03-30 | 13, 14 | 2002-08-02 | 2002-08-02 | 0d | 0d |  |  |  |  | 188743976 |
| 16 | 4 | **Abnahme** |  | 3.5d? | 2007-04-02 | 2007-04-05 |  | 2002-08-05 | 2002-08-08 | 3.5d | 0d |  | 36h | 3,600 | 3,600 | 188743977 |
| 17 | 4.1 | Abnahmedokument |  | 1d | 2007-04-02 | 2007-04-02 | 15 | 2002-08-05 | 2002-08-05 | 1d | 0d | Renke Holert | 8h | 800 | 800 | 188743978 |
| 18 | 4.2 | Testlauf |  | 1d? | 2007-04-03 | 2007-04-03 | 17 | 2002-08-06 | 2002-08-06 | 1d | 0d | Matthias Jäger; Helmut Reinke | 16h | 1,600 | 1,600 | 188743979 |
| 19 | 4.3 | Fehlerbehebung |  | 1d | 2007-04-04 | 2007-04-04 | 18 | 2002-08-07 | 2002-08-07 | 1d | 0d | Matthias Jäger | 8h | 800 | 800 | 188743980 |
| 20 | 4.4 | Liveschaltung der Website |  | 0.5d? | 2007-04-05 | 2007-04-05 | 19 | 2002-08-08 | 2002-08-08 | 0.5d | 0d | Steffen Reister | 4h | 400 | 400 | 188743981 |
| 21 | 4.5 | Projektabschluss | milestone | 0d | 2007-04-05 | 2007-04-05 | 20 | 2002-08-08 | 2002-08-08 | 0d | 0d |  |  |  |  | 188744007 |
