# Microsoft Office Project - Das Profibuch

Schedule from MS Project, 2007-01-01 to 2008-01-02.
Kapitel 12 - Beispielanwendungen
holert.com

## Calendars

- Standard: Mon-Fri 08:00-12:00, 13:00-17:00; Sat-Sun off.

## Resources

| Resource |
| --- |
| Matthias Jäger |
| Renke Holert |
| Helmut Reinke |
| Steffen Reister |
| Egbert Jeschke |

## Schedule

| ID | WBS | Task | Type | Duration | Start | Finish | Predecessors | Baseline start | Baseline finish | Baseline duration | Total slack | Baseline cost | Text1 |
| --- | --- | --- | --- | --- | --- | --- | --- | --- | --- | --- | --- | --- | --- |
| 1 | PM | **Projektmanagement** |  | 260d | 2007-01-01 | 2007-12-28 |  |  |  |  | 3d |  |  |
| 2 | PM.A | Projektmanagement |  | 52w | 2007-01-01 | 2007-12-28 |  |  |  |  | 3d |  |  |
| 3 | INI | **Initialisierung** |  | 50d | 2007-01-01 | 2007-03-09 |  | 2002-07-01 | 2002-07-02 | 2d | 0d | 1,600 | 188743752 |
| 4 | INI.A | Auftrag erteilt | milestone | 0w | 2007-01-01 | 2007-01-01 |  | 2002-07-01 | 2002-07-01 | 0d | 0d |  | 188743753 |
| 5 | INI.B | Marketingkonzept erstellen |  | 10w | 2007-01-01 | 2007-03-09 | 4 | 2002-07-01 | 2002-07-02 | 2d | 0d | 1,600 | 188743754 |
| 6 | ENT | **Entwurf Prototyp** |  | 75d | 2007-03-12 | 2007-06-22 |  | 2002-07-03 | 2002-07-10 | 6d | 0d | 5,600 | 188743755 |
| 7 | ENT.A | Designkonzept |  | 10w | 2007-03-12 | 2007-05-18 | 5 | 2002-07-03 | 2002-07-04 | 2d | 0d | 1,600 | 188743756 |
| 8 | ENT.C | Implementationskonzept |  | 5w | 2007-05-21 | 2007-06-22 | 7 | 2002-07-09 | 2002-07-09 | 1d | 0d | 800 | 188743758 |
| 9 | ENT.D | Abnahme Prototyp | milestone | 0w | 2007-06-22 | 2007-06-22 | 8 | 2002-07-10 | 2002-07-10 | 0d | 0d |  | 188743761 |
| 10 | REA | **Realisierung** |  | 78d | 2007-06-25 | 2007-10-10 |  | 2002-07-11 | 2002-08-02 | 17d | 0d | 47,200 | 188743972 |
| 11 | REA.A | ToDo Liste erstellen |  | 10w | 2007-06-25 | 2007-08-31 | 9 | 2002-07-11 | 2002-07-11 | 1d | 0d | 800 | 188743973 |
| 12 | REA.B | Inhalte erstellen |  | 5w | 2007-09-03 | 2007-10-05 | 11 | 2002-07-12 | 2002-08-01 | 15d | 3d | 36,000 | 188743974 |
| 13 | REA.C | Programmierung |  | 5w | 2007-09-06 | 2007-10-10 | 11FS+3d | 2002-07-17 | 2002-08-02 | 13d | 0d | 10,400 | 188743975 |
| 14 | REA.D | Website erstellt | milestone | 0w | 2007-10-10 | 2007-10-10 | 12, 13 | 2002-08-02 | 2002-08-02 | 0d | 0d |  | 188743976 |
| 15 | ABN | **Abnahme** |  | 60d | 2007-10-11 | 2008-01-02 |  | 2002-08-05 | 2002-08-08 | 3.5d | 0d | 3,600 | 188743977 |
| 16 | ABN.A | Abnahmedokument |  | 5w | 2007-10-11 | 2007-11-14 | 14 | 2002-08-05 | 2002-08-05 | 1d | 0d | 800 | 188743978 |
| 17 | ABN.C | Fehlerbehebung |  | 7w | 2007-11-15 | 2008-01-02 | 16 | 2002-08-07 | 2002-08-07 | 1d | 0d | 800 | 188743980 |
| 18 | ABN.D | Projektabschluss | milestone | 0w | 2008-01-02 | 2008-01-02 | 17 | 2002-08-08 | 2002-08-08 | 0d | 0d |  | 188744007 |
